# 2-2

Schedule from MS Project, 2023-09-14 to 2024-01-25, 2 hours a day, costs in €, A marks actual dates.
Universite Clermont Auvergne

## Calendars

- SAE: Mon-Fri 08:00-10:00; Sat-Sun off.

## Resources

| Resource | Rate |
| --- | --- |
| A_PE | 20 |
| K_MO | 20 |
| P_LE | 20 |
| D_DA | 20 |
| A_PI | 20 |

## Schedule

| ID | WBS | Task | Duration | Start | Finish | Predecessors | Complete | Remaining | Actual start | Total slack | Free slack | Resources | Work | Actual work | Cost | Actual cost |
| --- | --- | --- | --- | --- | --- | --- | --- | --- | --- | --- | --- | --- | --- | --- | --- | --- |
| 1 | 1 | **Étude de courbes de fréquence cardiaque** | 94.74d? | 2023-09-14 A | 2024-01-25 |  | 43% | 54.2d? |  | 0d |  |  | 742.1h | 319.05h | 14,842 | 6,381.09 |
| 2 | 1.1 | **1 - Management de projet** | 94.74d | 2023-09-14 A | 2024-01-25 |  | 74% | 24.6d |  | 0d |  |  | 185.5h | 142.74h | 3,710 | 2,854.87 |
| 3 | 1.1.1 | **1.1 - Recueil de besoins** | 38.5d | 2023-09-14 A | 2023-11-07 |  | 88% | 4.56d |  | 56.24d |  |  | 87h | 80.5h | 1,740 | 1,610 |
| 4 | 1.1.1.1 | 1.1.1 - Présentation general du projet | 2h | 2023-09-18 A | 2023-09-18 A | 13 | 100% |  |  |  |  | A_PE | 2h | 2h | 40 | 40 |
| 5 | 1.1.1.2 | 1.1.2 - Compte rendu 1 | 3h | 2023-09-22 A | 2023-09-22 A | 4, 12 | 100% |  |  |  |  | A_PE; A_PI; D_DA; K_MO; P_LE | 7h | 7h | 140 | 140 |
| 6 | 1.1.1.3 | 1.1.3 - Compte rendu 1 (v2) | 5h | 2023-10-05 A | 2023-10-06 A | 7 | 100% |  |  |  |  | A_PE; A_PI; D_DA; K_MO; P_LE | 25h | 25h | 500 | 500 |
| 7 | 1.1.1.4 | 1.1.4 - Backlog (users stories) | 5h | 2023-10-02 A | 2023-10-04 A | 5 | 100% |  |  |  |  | D_DA; P_LE | 10h | 10h | 200 | 200 |
| 8 | 1.1.1.5 | 1.1.5 - Compte Rendu (V2) | 7h | 2023-10-03 A | 2023-10-06 A | 5 | 100% |  |  |  |  | A_PE | 7h | 7h | 140 | 140 |
| 9 | 1.1.1.6 | 1.1.6 - Compte rendu 2 (V2) | 5h | 2023-10-06 A | 2023-10-10 A | 6 | 100% |  |  |  |  | A_PE | 5h | 5h | 100 | 100 |
| 10 | 1.1.1.7 | 1.1.7 - Rapport BDD | 2h | 2023-11-07 A | 2023-11-07 A | 37 | 100% |  |  |  |  | A_PE; P_LE; D_DA; K_MO; A_PI | 10h | 10h | 200 | 200 |
| 11 | 1.1.1.8 | **1.1.5 - Rendez vous** | 7d | 2023-09-14 A | 2023-09-25 |  | 50% | 3.5d |  | 87.74d |  |  | 21h | 14.5h | 420 | 290 |
| 12 | 1.1.1.8.1 | 1.1.5.1 - Avec le tuteur | 4.5h | 2023-09-18 A | 2023-09-25 |  | 78% | 1h |  | 87.99d |  | A_PE; A_PI; D_DA; K_MO; P_LE | 16h | 13.5h | 320 | 270 |
| 13 | 1.1.1.8.2 | 1.1.5.2 - Avec le client | 4.5h | 2023-09-14 | 2023-09-25 |  | 22% | 3.5h | 2023-09-15 | 18d | 14.5d | A_PE; A_PI; D_DA; K_MO; P_LE | 5h | 1h | 100 | 20 |
| 14 | 1.1.2 | **1.2 - Organisation du travail en équipe** | 10d | 2023-09-15 A | 2023-09-28 A |  | 100% |  |  |  |  |  | 8h | 8h | 160 | 160 |
| 15 | 1.1.2.1 | 1.2.1 - Mise en place du kanban | 2h | 2023-09-15 A | 2023-09-28 A |  | 100% |  |  |  |  | A_PE; D_DA | 2h | 2h | 40 | 40 |
| 16 | 1.1.2.2 | 1.2.2 - Mise en place du codefirst | 3h | 2023-09-25 A | 2023-09-26 A |  | 100% |  |  |  |  | D_DA | 3h | 3h | 60 | 60 |
| 17 | 1.1.2.3 | 1.2.3 - Mise en place du notion | 2h | 2023-09-15 A | 2023-09-15 A |  | 100% |  |  |  |  | D_DA; A_PE | 2h | 2h | 40 | 40 |
| 18 | 1.1.2.4 | 1.2.4 - Mise en place du discord | 0.5h | 2023-09-15 A | 2023-09-15 A |  | 100% |  |  |  |  | A_PE; A_PI | 1h | 1h | 20 | 20 |
| 19 | 1.1.3 | **1.3 - Planification du projet** | 16.5d | 2023-09-20 A | 2023-10-12 A |  | 100% |  |  |  |  |  | 31h | 31h | 620 | 620 |
| 20 | 1.1.3.1 | 1.3.1 - WBS | 6h | 2023-09-20 A | 2023-09-22 A | 5 | 100% |  |  |  |  | A_PE; K_MO | 10h | 10h | 200 | 200 |
| 21 | 1.1.3.2 | 1.3.2 - GANTT prévisionnel | 17h | 2023-09-29 A | 2023-10-12 A | 20 | 100% |  |  |  |  | A_PE; P_LE | 17h | 17h | 340 | 340 |
| 22 | 1.1.3.3 | 1.3.3 - PERT | 4h | 2023-10-09 A | 2023-10-11 A | 21 | 100% |  |  |  |  | A_PE; P_LE | 4h | 4h | 80 | 80 |
| 23 | 1.1.4 | **1.4 - Suivi de projet** | 91.24d | 2023-09-20 A | 2024-01-25 |  | 38% | 56.41d |  | 0d |  |  | 59.5h | 23.24h | 1,190 | 464.87 |
| 24 | 1.1.4.1 | 1.4.1 - Indicateurs de suivi de projet | 4h | 2023-11-22 A | 2023-11-24 A | 22 | 100% |  |  |  |  | D_DA; A_PE | 4h | 4h | 80 | 80 |
| 25 | 1.1.4.2 | 1.4.2 - Préparation des vidéos | 8h | 2024-01-02 | 2024-01-15 | 26 |  |  |  | 7.71d |  | A_PE; A_PI; D_DA; K_MO; P_LE | 15h |  | 300 |  |
| 26 | 1.1.4.3 | 1.4.3 - Préparation des rapports globaux | 8.2h | 2023-12-20 | 2024-01-02 | 67 |  |  |  | 7.71d | 0d | A_PE; A_PI; D_DA; K_MO; P_LE | 10h |  | 200 |  |
| 27 | 1.1.4.4 | 1.4.4 - Préparation oral 1 | 5h | 2023-11-14 A | 2023-11-24 A | 24 | 100% |  |  |  |  | A_PE; A_PI; D_DA; K_MO; P_LE | 13h | 13h | 260 | 260 |
| 28 | 1.1.4.5 | 1.4.5 - Préparation oral 2 | 12.48h | 2023-12-07 A | 2024-01-10 | 27 | 40% | 7.49h |  | 10.93d |  | A_PE; A_PI; K_MO; P_LE | 15h | 4.99h | 300 | 99.87 |
| 29 | 1.1.4.6 | 1.4.6 - GANTT réel | 1.75h | 2023-11-14 A | 2024-01-25 | 67 | 43% | 1h |  | 0d |  | A_PI; A_PE | 2h | 0.75h | 40 | 15 |
| 30 | 1.1.4.7 | 1.4.7 - Graphe de compétence | 0.5h | 2023-09-20 A | 2023-09-20 A |  | 100% |  |  |  |  | K_MO | 0.5h | 0.5h | 10 | 10 |

| ID | WBS | Task | Type | Duration | Start | Finish | Predecessors | Complete | Remaining | Total slack | Free slack | Resources | Work | Actual work | Cost | Actual cost |
| --- | --- | --- | --- | --- | --- | --- | --- | --- | --- | --- | --- | --- | --- | --- | --- | --- |
| 31 | 1.2 | **2 - Développement** |  | 81.48d? | 2023-09-25 A | 2024-01-16 |  | 33% | 54.28d? | 6.26d |  |  | 556.6h | 176.31h | 11,132 | 3,526.22 |
| 32 | 1.2.1 | **2.1 - Conception** |  | 36.58d | 2023-09-25 A | 2023-11-15 |  | 55% | 16.36d | 51.16d |  |  | 133h | 79.37h | 2,660 | 1,587.35 |
| 33 | 1.2.1.1 | 2.1.1 - Communication (reseaux) |  | 11.12h | 2023-10-06 A | 2023-11-15 | 34 | 10% | 10h | 10.01d | 0d | A_PE; P_LE | 20h | 1.12h | 400 | 22.4 |
| 34 | 1.2.1.2 | 2.1.2 - Architecture |  | 12h | 2023-09-29 A | 2023-11-08 | 35 | 10% | 10.8h | 0d |  | A_PE; D_DA | 14h | 1.2h | 280 | 24 |
| 35 | 1.2.1.3 | 2.1.3 - Diagramme de classes |  | 13.35h | 2023-09-25 A | 2023-10-27 | 37 | 52% | 6.34h | 0.88d | 0d | A_PE; A_PI; D_DA | 26h | 14.25h | 520 | 284.95 |
| 36 | 1.2.1.4 | 2.1.4 - Maquettes |  | 12h | 2023-09-28 A | 2023-10-04 A | 5 | 100% |  |  |  | A_PI | 12h | 12h | 240 | 240 |
| 37 | 1.2.1.5 | 2.1.5 - MCD & MLD |  | 8h | 2023-10-16 A | 2023-10-19 A | 36 | 100% |  |  |  | D_DA; P_LE; K_MO; A_PI; A_PE | 32h | 32h | 640 | 640 |
| 38 | 1.2.1.6 | 2.1.6 - Diagramme de cas d'utilisation |  | 10h | 2023-10-16 A | 2023-10-24 | 13 | 70% | 3h | 11.56d | 3.56d | K_MO; A_PE | 12h | 9h | 240 | 180 |
| 39 | 1.2.1.7 | 2.1.7 - Charte graphique |  | 16h | 2023-10-10 A | 2023-11-03 | 9 | 55% | 7.2h | 58.63d |  | A_PI | 16h | 8.8h | 320 | 176 |
| 40 | 1.2.1.8 | 2.1.8 - Logo |  | 1h | 2023-10-20 A | 2023-10-20 A |  | 100% |  |  |  | D_DA | 1h | 1h | 20 | 20 |
| 41 | 1.2.2 | **2.2 - Client Web et Mobile** |  | 45.58d? | 2023-10-27 A | 2024-01-01 |  | 19% | 36.95d? | 18.18d |  |  | 149.1h | 21.77h | 2,982 | 435.47 |
| 42 | 1.2.2.1 | 2.2.1 - Interface utilisateur client (Vues) |  | 15h? | 2023-11-06 A | 2023-12-26 | 34 | 20% | 12h? | 21.46d |  | A_PI | 15h | 3h | 300 | 60 |
| 43 | 1.2.2.2 | 2.2.2 - Gestion des données client |  | 57.32h? | 2023-11-13 A | 2023-12-27 | 34 | 11% | 51.28h? | 0.53d | 0.45d | A_PE; D_DA; P_LE | 117h | 10.87h | 2,340 | 217.47 |
| 44 | 1.2.2.3 | 2.2.3 - Authentification Web et Mobile client |  | 3h | 2023-12-28 A | 2024-01-01 | 33, 43, 47, 48, 49, 69, 70, 71, 72, 73, 74, 75 | 5% | 2.85h | 18.18d |  | A_PI; K_MO; D_DA | 3h | 0.15h | 60 | 3 |
| 45 | 1.2.2.4 | 2.2.4 - Récupération des données de fréquence cardiaque |  | 8h | 2023-10-27 A | 2023-11-10 | 34 | 41% | 4.75h | 54.16d |  | A_PE | 8h | 3.25h | 160 | 65 |
| 46 | 1.2.2.5 | 2.2.5 - Définitions des algoritmes d'analyse de la fréquence cardiaque | milestone | 0h | 2023-11-15 | 2023-11-22 | 33 |  |  | 39.9d |  | D_DA |  |  |  |  |
| 47 | 1.2.2.6 | 2.2.6 - Mise en place Bootstrap |  | 3.6h | 2023-10-28 A | 2023-11-09 | 34, 38 | 56% | 1.6h | 34.59d | 34.51d | A_PI | 3.6h | 2h | 72 | 40 |
| 48 | 1.2.2.7 | 2.2.7 - Mise en place talwind |  | 1.5h | 2023-10-28 A | 2023-10-30 A | 34, 38 | 100% |  |  |  | A_PI | 1.5h | 1.5h | 30 | 30 |
| 49 | 1.2.2.8 | 2.2.8 - Mise en place lead PHPStorm |  | 1h | 2023-10-28 A | 2023-10-30 A | 34, 38 | 100% |  |  |  | D_DA | 1h | 1h | 20 | 20 |
| 50 | 1.2.3 | **2.3 - Web admin et monitorin** |  | 28.18d | 2023-11-28 A | 2024-01-08 |  | 30% | 19.73d | 13.15d |  |  | 25h | 8.82h | 500 | 176.4 |
| 51 | 1.2.3.1 | 2.3.1 - Authentification admin et monitoring |  | 9.7h | 2023-12-27 A | 2024-01-08 | 33 | 30% | 6.79h | 13.15d |  | A_PE; D_DA | 15h | 5.82h | 300 | 116.4 |
| 52 | 1.2.3.2 | 2.3.2 - Interface utilisateur admin (Vues) |  | 10h | 2023-11-28 A | 2023-12-08 | 34 | 30% | 7h | 34.08d |  | A_PI | 10h | 3h | 200 | 60 |
| 53 | 1.2.4 | **2.4 - Base de données** |  | 59.31d | 2023-10-20 A | 2024-01-11 |  | 11% | 52.62d | 9.93d |  |  | 25h | 2h | 500 | 40 |
| 54 | 1.2.4.1 | 2.4.1 - Création des tables |  | 2h | 2023-10-20 A | 2023-10-20 A | 43 | 100% |  |  |  | P_LE | 2h | 2h | 40 | 40 |
| 55 | 1.2.4.2 | 2.4.2 - Ajout des données |  | 1.73h | 2023-10-23 | 2023-10-23 | 54 |  |  | 44.14d | 35.64d | A_PE; D_DA | 3h |  | 60 |  |
| 56 | 1.2.4.3 | 2.4.3 - Mise en place d'un système de backup |  | 6h | 2023-10-23 | 2023-12-12 | 54 |  |  | 8.5d | 0d | A_PE; D_DA | 12h |  | 240 |  |
| 57 | 1.2.4.4 | 2.4.4 - Création des fonctions |  | 4h | 2023-11-03 | 2023-11-28 | 54 |  |  | 35.07d |  | A_PI | 4h |  | 80 |  |
| 58 | 1.2.4.5 | 2.4.5 - Création des index |  | 4h | 2024-01-01 | 2024-01-11 | 55, 56 |  |  | 3.67d |  | A_PE; D_DA | 4h |  | 80 |  |

| ID | WBS | Task | Duration | Start | Finish | Predecessors | Complete | Remaining | Total slack | Free slack | Resources | Work | Actual work | Cost | Actual cost |
| --- | --- | --- | --- | --- | --- | --- | --- | --- | --- | --- | --- | --- | --- | --- | --- |
| 59 | 1.2.5 | **2.5 - Serveur et communication de services** | 49.9d | 2023-11-08 | 2024-01-16 |  |  |  | 6.26d |  |  | 48h |  | 960 |  |
| 60 | 1.2.5.1 | 2.5.1 - Authentification serveur | 4h | 2023-11-15 | 2023-12-29 | 33 |  |  | 3.75d |  | A_PI; K_MO | 4h |  | 80 |  |
| 61 | 1.2.5.2 | 2.5.2 - Stockage cloud | 3.33h | 2024-01-04 | 2024-01-05 | 60, 62 |  |  | 6.26d | 0d | D_DA; A_PE; A_PI | 10h |  | 200 |  |
| 62 | 1.2.5.3 | 2.5.3 - Routage | 18h | 2023-11-08 | 2024-01-04 | 34 |  |  | 6.26d | 0d | A_PE; A_PI; D_DA | 18h |  | 360 |  |
| 63 | 1.2.5.4 | 2.5.4 - Gestion des données serveur | 13.96h | 2024-01-05 | 2024-01-16 | 61 |  |  | 6.26d |  | A_PI; A_PE; D_DA | 16h |  | 320 |  |
| 64 | 1.2.6 | **2.6 - Integration continue et livraison continue (CI/ CD)** | 38.31d | 2023-10-27 A | 2023-12-20 |  | 11% | 33.96d | 25.45d |  |  | 106h | 7.85h | 2,120 | 157 |
| 65 | 1.2.6.1 | 2.6.1 - Tests | 48.64h | 2023-10-27 A | 2023-12-15 | 34 | 9% | 44.19h | 0d |  | A_PE; A_PI; D_DA; K_MO; P_LE | 78h | 4.45h | 1,560 | 89 |
| 66 | 1.2.6.2 | 2.6.2 - Conteneurisation et déploiement | 8h | 2023-10-27 A | 2023-12-06 | 34 | 30% | 5.6h | 35.76d |  | A_PE; D_DA | 8h | 2.4h | 160 | 48 |
| 67 | 1.2.6.3 | 2.6.3 - Documentations (swagger, schéma, …) | 6.67h | 2023-11-15 A | 2023-12-20 | 65 | 5% | 6.33h | 0d |  | A_PE; A_PI; D_DA | 20h | 1h | 400 | 20 |
| 68 | 1.2.7 | **2.7 Configuration** | 28.08d | 2023-10-06 A | 2023-11-15 |  | 77% | 6.5d | 51.16d |  |  | 70.5h | 56.5h | 1,410 | 1,130 |
| 69 | 1.2.7.1 | 2.7.1 - Installation Twig | 0.5h | 2023-10-06 A | 2023-10-06 A | 34 | 100% |  |  |  | A_PI | 0.5h | 0.5h | 10 | 10 |
| 70 | 1.2.7.2 | 2.7.2 - Bootstrap | 2h | 2023-10-06 A | 2023-10-06 A | 34 | 100% |  |  |  | A_PI | 2h | 2h | 40 | 40 |
| 71 | 1.2.7.3 | 2.7.3 - PHP Unite | 10h | 2023-10-11 A | 2023-10-16 A | 43 | 100% |  |  |  | D_DA; P_LE | 20h | 20h | 400 | 400 |
| 72 | 1.2.7.4 | 2.7.4 - Node | 6h | 2023-10-11 A | 2023-10-13 A | 43 | 100% |  |  |  | A_PI | 6h | 6h | 120 | 120 |
| 73 | 1.2.7.5 | 2.7.5 - Autoloader | 2h | 2023-10-06 A | 2023-10-06 A | 34 | 100% |  |  |  | A_PI | 2h | 2h | 40 | 40 |
| 74 | 1.2.7.6 | 2.7.6 - Composer | 2h | 2023-10-06 A | 2023-10-06 A | 34 | 100% |  |  |  | A_PI; D_DA | 2h | 2h | 40 | 40 |
| 75 | 1.2.7.7 | 2.7.7 - Architecture Repository | 28h | 2023-10-06 A | 2023-11-15 | 34 | 57% | 12h | 31.31d | 31.23d | A_PI; K_MO | 28h | 16h | 560 | 320 |
| 76 | 1.2.7.8 | 2.7.8 - Mise en place de la Documentation et Readme.md | 10h | 2023-10-06 A | 2023-10-20 | 37 | 80% | 2h | 68.24d |  | A_PE | 10h | 8h | 200 | 160 |
